# catalog_launch_filter

Schedule from MS Project, 2015-11-23 to 2015-12-24, A marks actual dates.
Microsoft

## Calendars

- Standard: Mon-Fri 08:00-12:00, 13:00-17:00; Sat-Sun off.

## Resources

| Resource |
| --- |
| Manager |
| Designer |
| Printer |
| Client |
| Photographer |

## Schedule

| ID | WBS | Task | Type | Duration | Start | Finish | Predecessors | Complete | Remaining | Total slack | Resources | Work | Actual work |
| --- | --- | --- | --- | --- | --- | --- | --- | --- | --- | --- | --- | --- | --- |
| 1 | 1 | **New Catalog Launch Preparation** |  | 24d | 2015-11-23 A | 2015-12-24 |  | 40% | 14.5d | 0d |  | 248h | 120h |
| 2 | 1.1 | **Phase 1 - Planning** |  | 8d | 2015-11-23 A | 2015-12-02 A |  | 100% |  |  |  | 96h | 96h |
| 3 | 1.1.1 | Identify the launch team |  | 2d | 2015-11-23 A | 2015-11-24 A |  | 100% |  |  | Manager | 16h | 16h |
| 4 | 1.1.2 | Determine catalog objectives |  | 1d | 2015-11-25 A | 2015-11-25 A | 3 | 100% |  |  | Client; Manager | 16h | 16h |
| 5 | 1.1.3 | Identify budget requirements |  | 1d | 2015-11-26 A | 2015-11-26 A | 4 | 100% |  |  | Client; Manager | 16h | 16h |
| 6 | 1.1.4 | Obtain launch budget approval |  | 1d | 2015-11-27 A | 2015-11-27 A | 5 | 100% |  |  | Client; Manager | 16h | 16h |
| 7 | 1.1.5 | Define launch goals (launch timing and publicity objectives) |  | 1d | 2015-11-30 A | 2015-11-30 A | 6 | 100% |  |  | Client; Manager | 16h | 16h |
| 8 | 1.1.6 | Send RFQ |  | 1d | 2015-12-01 A | 2015-12-01 A | 7 | 100% |  |  | Manager | 8h | 8h |
| 9 | 1.1.7 | Identify print partners |  | 1d | 2015-12-02 A | 2015-12-02 A | 8 | 100% |  |  | Manager | 8h | 8h |
| 10 | 1.1.8 | Planning COMPLETE | milestone | 0d | 2015-12-02 A | 2015-12-02 A | 9 | 100% |  |  |  |  |  |
| 11 | 1.2 | **Phase 2 - Development** |  | 10d | 2015-12-03 A | 2015-12-16 |  | 15% | 8.5d | 0d |  | 104h | 24h |
| 12 | 1.2.1 | Define creative brief |  | 3d | 2015-12-03 A | 2015-12-07 | 10 | 50% | 1.5d | 0d | Client; Manager | 48h | 24h |
| 13 | 1.2.2 | Set design scope |  | 1d | 2015-12-08 | 2015-12-08 | 12 |  |  | 0d | Manager | 8h |  |
| 14 | 1.2.3 | Create images |  | 2d | 2015-12-09 | 2015-12-10 | 13 |  |  | 0d | Photographer | 16h |  |
| 15 | 1.2.4 | Create catalog |  | 4d | 2015-12-11 | 2015-12-16 | 14 |  |  | 0d | Designer | 32h |  |
| 16 | 1.2.5 | Development Phase COMPLETE | milestone | 0d | 2015-12-16 | 2015-12-16 | 15 |  |  | 0d |  |  |  |
| 17 | 1.3 | **Phase 3 - Execution** |  | 6d | 2015-12-17 | 2015-12-24 |  |  |  | 0d |  | 48h |  |
| 18 | 1.3.1 | Upload files and data to print house |  | 1d | 2015-12-17 | 2015-12-17 | 16 |  |  | 0d | Manager | 8h |  |
| 19 | 1.3.2 | Print Catalog |  | 5d | 2015-12-18 | 2015-12-24 | 18 |  |  | 0d | Printer | 40h |  |
