# catalog_launch_cost

Schedule from MS Project, 2015-11-23 to 2015-12-31.
Microsoft

## Calendars

- Standard: Mon-Fri 08:00-12:00, 13:00-17:00; Sat-Sun off.

## Resources

| Resource |
| --- |
| Manager |
| Designer |
| Printer |
| Client |
| Photographer |

## Schedule

| ID | WBS | Task | Type | Duration | Start | Finish | Predecessors | Baseline start | Baseline finish | Baseline duration | Baseline 1 start | Baseline 1 finish | Total slack | Free slack | Resources | Work |
| --- | --- | --- | --- | --- | --- | --- | --- | --- | --- | --- | --- | --- | --- | --- | --- | --- |
| 1 | 1 | **New Catalog Launch Preparation** |  | 29d | 2015-11-23 | 2015-12-31 |  | 2012-12-03 | 2013-01-03 | 24d | 2012-12-03 | 2013-01-10 | 0d |  |  | 336h |
| 2 | 1.1 | **Phase 1 - Planning** |  | 8d | 2015-11-23 | 2015-12-02 |  | 2012-12-03 | 2012-12-12 | 8d | 2012-12-03 | 2012-12-12 | 0d |  |  | 96h |
| 3 | 1.1.1 | Identify the launch team |  | 2d | 2015-11-23 | 2015-11-24 |  | 2012-12-03 | 2012-12-04 | 2d | 2012-12-03 | 2012-12-04 | 0d |  | Manager | 16h |
| 4 | 1.1.2 | Determine catalog objectives |  | 1d | 2015-11-25 | 2015-11-25 | 3 | 2012-12-05 | 2012-12-05 | 1d | 2012-12-05 | 2012-12-05 | 0d |  | Client; Manager | 16h |
| 5 | 1.1.3 | Identify budget requirements |  | 1d | 2015-11-26 | 2015-11-26 | 4 | 2012-12-06 | 2012-12-06 | 1d | 2012-12-06 | 2012-12-06 | 0d |  | Client; Manager | 16h |
| 6 | 1.1.4 | Obtain launch budget approval |  | 1d | 2015-11-27 | 2015-11-27 | 5 | 2012-12-07 | 2012-12-07 | 1d | 2012-12-07 | 2012-12-07 | 0d |  | Client; Manager | 16h |
| 7 | 1.1.5 | Define launch goals (launch timing and publicity objectives) |  | 1d | 2015-11-30 | 2015-11-30 | 6 | 2012-12-10 | 2012-12-10 | 1d | 2012-12-10 | 2012-12-10 | 0d |  | Client; Manager | 16h |
| 8 | 1.1.6 | Send RFQ |  | 1d | 2015-12-01 | 2015-12-01 | 7 | 2012-12-11 | 2012-12-11 | 1d | 2012-12-11 | 2012-12-11 | 0d |  | Manager | 8h |
| 9 | 1.1.7 | Identify print partners |  | 1d | 2015-12-02 | 2015-12-02 | 8 | 2012-12-12 | 2012-12-12 | 1d | 2012-12-12 | 2012-12-12 | 0d |  | Manager | 8h |
| 10 | 1.1.8 | Planning COMPLETE | milestone | 0d | 2015-12-02 | 2015-12-02 | 9 | 2012-12-12 | 2012-12-12 | 0d | 2012-12-12 | 2012-12-12 | 0d |  |  |  |
| 11 | 1.2 | **Phase 2 - Development** |  | 10d | 2015-12-03 | 2015-12-16 |  | 2012-12-13 | 2012-12-26 | 10d | 2012-12-13 | 2012-12-26 | 0d |  |  | 104h |
| 12 | 1.2.1 | Define creative brief |  | 3d | 2015-12-03 | 2015-12-07 | 10 | 2012-12-13 | 2012-12-17 | 3d | 2012-12-13 | 2012-12-17 | 0d |  | Client; Manager | 48h |
| 13 | 1.2.2 | Set design scope |  | 1d | 2015-12-08 | 2015-12-08 | 12 | 2012-12-18 | 2012-12-18 | 1d | 2012-12-18 | 2012-12-18 | 0d |  | Manager | 8h |
| 14 | 1.2.3 | Create images |  | 2d | 2015-12-09 | 2015-12-10 | 13 | 2012-12-19 | 2012-12-20 | 2d | 2012-12-19 | 2012-12-20 | 0d |  | Photographer | 16h |
| 15 | 1.2.4 | Create catalog |  | 4d | 2015-12-11 | 2015-12-16 | 14 | 2012-12-21 | 2012-12-26 | 4d | 2012-12-21 | 2012-12-26 | 0d |  | Designer | 32h |
| 16 | 1.2.5 | Development Phase COMPLETE | milestone | 0d | 2015-12-16 | 2015-12-16 | 15 | 2012-12-26 | 2012-12-26 | 0d | 2012-12-26 | 2012-12-26 | 0d |  |  |  |
| 17 | 1.3 | **Review** |  | 11d | 2015-12-17 | 2015-12-31 |  |  |  |  | 2012-12-27 | 2013-01-10 | 0d |  |  | 88h |
| 18 | 1.3.1 | send mock-up to client |  | 1d | 2015-12-17 | 2015-12-17 | 16 |  |  |  | 2012-12-27 | 2012-12-27 | 0d |  | Designer | 8h |
| 19 | 1.3.2 | Client Review/Report |  | 5d | 2015-12-18 | 2015-12-24 | 18 |  |  |  | 2012-12-28 | 2013-01-03 | 0d |  | Client | 40h |
| 20 | 1.3.3 | Comments received and catalog updated |  | 5d | 2015-12-25 | 2015-12-31 | 19 |  |  |  | 2013-01-04 | 2013-01-10 | 0d |  | Designer | 40h |
| 21 | 1.4 | **Phase 3 - Execution** |  | 6d | 2015-12-17 | 2015-12-24 |  | 2012-12-27 | 2013-01-03 | 6d | 2012-12-27 | 2013-01-03 | 5d |  |  | 48h |
| 22 | 1.4.1 | Upload files and data to print house |  | 1d | 2015-12-17 | 2015-12-17 | 16 | 2012-12-27 | 2012-12-27 | 1d | 2012-12-27 | 2012-12-27 | 5d | 0d | Manager | 8h |
| 23 | 1.4.2 | Print Catalog |  | 5d | 2015-12-18 | 2015-12-24 | 22 | 2012-12-28 | 2013-01-03 | 5d | 2012-12-28 | 2013-01-03 | 5d |  | Printer | 40h |
