# catalog_launch_cp

Schedule from MS Project, 2015-11-23 to 2016-02-10.
Microsoft

## Calendars

- Standard: Mon-Fri 08:00-12:00, 13:00-17:00; Sat-Sun off.

## Resources

| Resource |
| --- |
| Manager |
| Designer |
| Printer |
| Client |
| Photographer |

## Schedule

| ID | WBS | Task | Type | Duration | Start | Finish | Predecessors | Total slack | Free slack | Constraint | Resources | Work |
| --- | --- | --- | --- | --- | --- | --- | --- | --- | --- | --- | --- | --- |
| 1 | 1 | **New Catalog Launch Preparation** |  | 58d | 2015-11-23 | 2016-02-10 |  | 0d |  |  |  | 248h |
| 2 | 1.1 | **Phase 1 - Planning** |  | 8d | 2015-11-23 | 2015-12-02 |  | 16d |  |  |  | 96h |
| 3 | 1.1.1 | Identify the launch team |  | 2d | 2015-11-23 | 2015-11-24 |  | 16d | 0d |  | Manager | 16h |
| 4 | 1.1.2 | Determine catalog objectives |  | 1d | 2015-11-25 | 2015-11-25 | 3 | 16d | 0d |  | Client; Manager | 16h |
| 5 | 1.1.3 | Identify budget requirements |  | 1d | 2015-11-26 | 2015-11-26 | 4 | 16d | 0d |  | Client; Manager | 16h |
| 6 | 1.1.4 | Obtain launch budget approval |  | 1d | 2015-11-27 | 2015-11-27 | 5 | 16d | 0d |  | Client; Manager | 16h |
| 7 | 1.1.5 | Define launch goals (launch timing and publicity objectives) |  | 1d | 2015-11-30 | 2015-11-30 | 6 | 16d | 0d |  | Client; Manager | 16h |
| 8 | 1.1.6 | Send RFQ |  | 1d | 2015-12-01 | 2015-12-01 | 7 | 16d | 0d |  | Manager | 8h |
| 9 | 1.1.7 | Identify print partners |  | 1d | 2015-12-02 | 2015-12-02 | 8 | 16d | 0d |  | Manager | 8h |
| 10 | 1.1.8 | Planning COMPLETE | milestone | 0d | 2015-12-02 | 2015-12-02 | 9 | 16d | 0d |  |  |  |
| 11 | 1.2 | **Phase 2 - Development** |  | 34d | 2015-12-03 | 2016-01-19 |  | 10d |  |  |  | 104h |
| 12 | 1.2.1 | Define creative brief |  | 3d | 2015-12-03 | 2015-12-07 | 10 | 16d | 0d |  | Client; Manager | 48h |
| 13 | 1.2.2 | Set design scope |  | 1d | 2015-12-08 | 2015-12-08 | 12 | 16d |  |  | Manager | 8h |
| 14 | 1.2.3 | Create images |  | 2d | 2015-12-31 | 2016-01-01 | 13 | 0d |  | must start on 2015-12-31 | Photographer | 16h |
| 15 | 1.2.4 | Create catalog |  | 4d | 2015-12-31 | 2016-01-19 | 14SS | 10d | 0d |  | Designer | 32h |
| 16 | 1.2.5 | Development Phase COMPLETE | milestone | 0d | 2016-01-19 | 2016-01-19 | 15 | 10d |  |  |  |  |
| 17 | 1.3 | **Phase 3 - Execution** |  | 6d | 2016-02-03 | 2016-02-10 |  | 0d |  |  |  | 48h |
| 18 | 1.3.1 | Upload files and data to print house |  | 1d | 2016-02-03 | 2016-02-03 | 16 | 0d |  | start no earlier than 2016-02-03 | Manager | 8h |
| 19 | 1.3.2 | Print Catalog |  | 5d | 2016-02-04 | 2016-02-10 | 18 | 0d |  |  | Printer | 40h |
