# catalog_launch_pay_rates

Schedule from MS Project, 2015-11-23 to 2015-12-24, costs in $.
Microsoft

## Calendars

- Standard: Mon-Fri 08:00-12:00, 13:00-17:00; Sat-Sun off.

## Resources

| Resource | Rate |
| --- | --- |
| Manager | 25 |
| Designer |  |
| Printer |  |
| Client |  |
| Photographer |  |

## Schedule

| ID | WBS | Task | Type | Duration | Start | Finish | Predecessors | Total slack | Resources | Work | Cost |
| --- | --- | --- | --- | --- | --- | --- | --- | --- | --- | --- | --- |
| 1 | 1 | **New Catalog Launch Preparation** |  | 24d | 2015-11-23 | 2015-12-24 |  | 0d |  | 248h | 2,600 |
| 2 | 1.1 | **Phase 1 - Planning** |  | 8d | 2015-11-23 | 2015-12-02 |  | 0d |  | 96h | 1,600 |
| 3 | 1.1.1 | Identify the launch team |  | 2d | 2015-11-23 | 2015-11-24 |  | 0d | Manager | 16h | 400 |
| 4 | 1.1.2 | Determine catalog objectives |  | 1d | 2015-11-25 | 2015-11-25 | 3 | 0d | Client; Manager | 16h | 200 |
| 5 | 1.1.3 | Identify budget requirements |  | 1d | 2015-11-26 | 2015-11-26 | 4 | 0d | Client; Manager | 16h | 200 |
| 6 | 1.1.4 | Obtain launch budget approval |  | 1d | 2015-11-27 | 2015-11-27 | 5 | 0d | Client; Manager | 16h | 200 |
| 7 | 1.1.5 | Define launch goals (launch timing and publicity objectives) |  | 1d | 2015-11-30 | 2015-11-30 | 6 | 0d | Client; Manager | 16h | 200 |
| 8 | 1.1.6 | Send RFQ |  | 1d | 2015-12-01 | 2015-12-01 | 7 | 0d | Manager | 8h | 200 |
| 9 | 1.1.7 | Identify print partners |  | 1d | 2015-12-02 | 2015-12-02 | 8 | 0d | Manager | 8h | 200 |
| 10 | 1.1.8 | Planning COMPLETE | milestone | 0d | 2015-12-02 | 2015-12-02 | 9 | 0d |  |  |  |
| 11 | 1.2 | **Phase 2 - Development** |  | 10d | 2015-12-03 | 2015-12-16 |  | 0d |  | 104h | 800 |
| 12 | 1.2.1 | Define creative brief |  | 3d | 2015-12-03 | 2015-12-07 | 10 | 0d | Client; Manager | 48h | 600 |
| 13 | 1.2.2 | Set design scope |  | 1d | 2015-12-08 | 2015-12-08 | 12 | 0d | Manager | 8h | 200 |
| 14 | 1.2.3 | Create images |  | 2d | 2015-12-09 | 2015-12-10 | 13 | 0d | Photographer | 16h |  |
| 15 | 1.2.4 | Create catalog |  | 4d | 2015-12-11 | 2015-12-16 | 14 | 0d | Designer | 32h |  |
| 16 | 1.2.5 | Development Phase COMPLETE | milestone | 0d | 2015-12-16 | 2015-12-16 | 15 | 0d |  |  |  |
| 17 | 1.3 | **Phase 3 - Execution** |  | 6d | 2015-12-17 | 2015-12-24 |  | 0d |  | 48h | 200 |
| 18 | 1.3.1 | Upload fles and data to print house |  | 1d | 2015-12-17 | 2015-12-17 | 16 | 0d | Manager | 8h | 200 |
| 19 | 1.3.2 | Print Catalog |  | 5d | 2015-12-18 | 2015-12-24 | 18 | 0d | Printer | 40h |  |
