# catalog_launch_constraint

Schedule from MS Project, 2012-12-03 to 2013-01-08.
Microsoft

## Calendars

- Standard: Mon-Fri 08:00-12:00, 13:00-17:00; Sat-Sun off.

## Resources

| Resource |
| --- |
| Manager |
| Designer |
| Printer |
| Client |
| Photographer |

## Schedule

| ID | WBS | Task | Type | Duration | Start | Finish | Predecessors | Total slack | Free slack | Constraint | Resources | Work |
| --- | --- | --- | --- | --- | --- | --- | --- | --- | --- | --- | --- | --- |
| 1 | 1 | **New Catalog Launch Preparation** |  | 27d | 2012-12-03 | 2013-01-08 |  | 0d |  |  |  | 248h |
| 2 | 1.1 | **Phase 1 - Planning** |  | 8d | 2012-12-03 | 2012-12-12 |  | 5d |  |  |  | 96h |
| 3 | 1.1.1 | Identify the launch team |  | 2d | 2012-12-03 | 2012-12-04 |  | 5d | 0d |  | Manager | 16h |
| 4 | 1.1.2 | Determine catalog objectives |  | 1d | 2012-12-05 | 2012-12-05 | 3 | 5d | 0d |  | Client; Manager | 16h |
| 5 | 1.1.3 | Identify budget requirements |  | 1d | 2012-12-06 | 2012-12-06 | 4 | 5d | 0d |  | Client; Manager | 16h |
| 6 | 1.1.4 | Obtain launch budget approval |  | 1d | 2012-12-07 | 2012-12-07 | 5 | 5d | 0d |  | Client; Manager | 16h |
| 7 | 1.1.5 | Define launch goals (launch timing and publicity objectives) |  | 1d | 2012-12-10 | 2012-12-10 | 6 | 5d | 0d |  | Client; Manager | 16h |
| 8 | 1.1.6 | Send RFQ |  | 1d | 2012-12-11 | 2012-12-11 | 7 | 5d | 0d |  | Manager | 8h |
| 9 | 1.1.7 | Identify print partners |  | 1d | 2012-12-12 | 2012-12-12 | 8 | 5d | 0d |  | Manager | 8h |
| 10 | 1.1.8 | Planning COMPLETE | milestone | 0d | 2012-12-12 | 2012-12-12 | 9 | 5d | 0d |  |  |  |
| 11 | 1.2 | **Phase 2 - Development** |  | 13d | 2012-12-13 | 2012-12-31 |  | 0d |  |  |  | 104h |
| 12 | 1.2.1 | Define creative brief |  | 3d | 2012-12-13 | 2012-12-17 | 10 | 5d | 0d |  | Client; Manager | 48h |
| 13 | 1.2.2 | Set design scope |  | 1d | 2012-12-18 | 2012-12-18 | 12 | 5d |  |  | Manager | 8h |
| 14 | 1.2.3 | Create images |  | 2d | 2012-12-26 | 2012-12-27 | 13 | 0d |  | must start on 2012-12-26 | Photographer | 16h |
| 15 | 1.2.4 | Create catalog |  | 4d | 2012-12-26 | 2012-12-31 | 14SS | 0d |  |  | Designer | 32h |
| 16 | 1.2.5 | Development Phase COMPLETE | milestone | 0d | 2012-12-31 | 2012-12-31 | 15 | 0d |  |  |  |  |
| 17 | 1.3 | **Phase 3 - Execution** |  | 6d | 2013-01-01 | 2013-01-08 |  | 0d |  |  |  | 48h |
| 18 | 1.3.1 | Upload fles and data to print house |  | 1d | 2013-01-01 | 2013-01-01 | 16 | 0d |  |  | Manager | 8h |
| 19 | 1.3.2 | Print Catalog |  | 5d | 2013-01-02 | 2013-01-08 | 18 | 0d |  |  | Printer | 40h |
