# catalog_launch_split

Schedule from MS Project, 2012-12-03 to 2013-01-14, A marks actual dates.
Microsoft

## Calendars

- Standard: Mon-Fri 08:00-12:00, 13:00-17:00; Sat-Sun off.

## Resources

| Resource |
| --- |
| Manager |
| Designer |
| Printer |
| Client |
| Photographer |

## Schedule

| ID | WBS | Task | Type | Duration | Start | Finish | Predecessors | Complete | Remaining | Total slack | Constraint | Resources | Work | Actual work |
| --- | --- | --- | --- | --- | --- | --- | --- | --- | --- | --- | --- | --- | --- | --- |
| 1 | 1 | **New Catalog Launch Preparation** |  | 31d | 2012-12-03 A | 2013-01-14 |  | 67% | 10.33d | 0d |  |  | 248h | 184h |
| 2 | 1.1 | **Phase 1 - Planning** |  | 8d | 2012-12-03 A | 2012-12-12 A |  | 100% |  |  |  |  | 96h | 96h |
| 3 | 1.1.1 | Identify the launch team |  | 2d | 2012-12-03 A | 2012-12-04 A |  | 100% |  |  |  | Manager | 16h | 16h |
| 4 | 1.1.2 | Determine catalog objectives |  | 1d | 2012-12-05 A | 2012-12-05 A | 3 | 100% |  |  |  | Client; Manager | 16h | 16h |
| 5 | 1.1.3 | Identify budget requirements |  | 1d | 2012-12-06 A | 2012-12-06 A | 4 | 100% |  |  |  | Client; Manager | 16h | 16h |
| 6 | 1.1.4 | Obtain launch budget approval |  | 1d | 2012-12-07 A | 2012-12-07 A | 5 | 100% |  |  |  | Client; Manager | 16h | 16h |
| 7 | 1.1.5 | Define launch goals (launch timing and publicity objectives) |  | 1d | 2012-12-10 A | 2012-12-10 A | 6 | 100% |  |  |  | Client; Manager | 16h | 16h |
| 8 | 1.1.6 | Send RFQ |  | 1d | 2012-12-11 A | 2012-12-11 A | 7 | 100% |  |  |  | Manager | 8h | 8h |
| 9 | 1.1.7 | Identify print partners |  | 1d | 2012-12-12 A | 2012-12-12 A | 8 | 100% |  |  |  | Manager | 8h | 8h |
| 10 | 1.1.8 | Planning COMPLETE | milestone | 0d | 2012-12-12 A | 2012-12-12 A | 9 | 100% |  |  |  |  |  |  |
| 11 | 1.2 | **Phase 2 - Development** |  | 17d | 2012-12-13 A | 2013-01-04 |  | 80% | 3.4d | 0d |  |  | 104h | 88h |
| 12 | 1.2.1 | Define creative brief |  | 3d | 2012-12-13 A | 2012-12-17 A | 10 | 100% |  |  |  | Client; Manager | 48h | 48h |
| 13 | 1.2.2 | Set design scope |  | 1d | 2012-12-18 A | 2012-12-18 A | 12 | 100% |  |  |  | Manager | 8h | 8h |
| 14 | 1.2.3 | Create images |  | 2d | 2012-12-26 A | 2012-12-27 A | 13 | 100% |  |  | must start on 2012-12-26 | Photographer | 16h | 16h |
| 15 | 1.2.4 | Create catalog |  | 4d | 2012-12-26 A | 2013-01-04 | 14SS | 50% | 2d | 0d |  | Designer | 32h | 16h |
| 16 | 1.2.5 | Development Phase COMPLETE | milestone | 0d | 2013-01-04 | 2013-01-04 | 15 |  |  | 0d |  |  |  |  |
| 17 | 1.3 | **Phase 3 - Execution** |  | 6d | 2013-01-07 | 2013-01-14 |  |  |  | 0d |  |  | 48h |  |
| 18 | 1.3.1 | Upload fles and data to print house |  | 1d | 2013-01-07 | 2013-01-07 | 16 |  |  | 0d |  | Manager | 8h |  |
| 19 | 1.3.2 | Print Catalog |  | 5d | 2013-01-08 | 2013-01-14 | 18 |  |  | 0d |  | Printer | 40h |  |
