# New Product Launch

Schedule from MS Project, 2013-03-04 to 2013-04-22, A marks actual dates.

## Calendars

- Standard: Mon-Fri 08:00-12:00, 13:00-17:00; Sat-Sun off.

## Resources

| Resource |
| --- |
| Manager |
| Designer |
| Developer |
| Client |

## Schedule

| ID | WBS | Task | Type | Duration | Start | Finish | Predecessors | Complete | Remaining | Baseline start | Baseline finish | Baseline duration | Total slack | Free slack | Constraint | Resources | Work | Actual work |
| --- | --- | --- | --- | --- | --- | --- | --- | --- | --- | --- | --- | --- | --- | --- | --- | --- | --- | --- |
| 1 | 1 | **New Site Launch Preparation** |  | 36d | 2013-03-04 A | 2013-04-22 |  | 78% | 8d | 2013-03-04 | 2013-04-09 | 27d | 0d |  |  |  | 280h | 232h |
| 2 | 1.1 | **Phase 1 - Planning** |  | 8d | 2013-03-04 A | 2013-03-13 A |  | 100% |  | 2013-03-04 | 2013-03-13 | 8d |  |  |  |  | 96h | 96h |
| 3 | 1.1.1 | Identify the launch team |  | 2d | 2013-03-04 A | 2013-03-05 A |  | 100% |  | 2013-03-04 | 2013-03-05 | 2d |  |  |  | Manager | 16h | 16h |
| 4 | 1.1.2 | Determine site objectives |  | 1d | 2013-03-06 A | 2013-03-06 A | 3 | 100% |  | 2013-03-06 | 2013-03-06 | 1d |  |  |  | Client; Manager | 16h | 16h |
| 5 | 1.1.3 | Identify budget requirements |  | 1d | 2013-03-07 A | 2013-03-07 A | 4 | 100% |  | 2013-03-07 | 2013-03-07 | 1d |  |  |  | Client; Manager | 16h | 16h |
| 6 | 1.1.4 | Obtain launch budget approval |  | 1d | 2013-03-08 A | 2013-03-08 A | 5 | 100% |  | 2013-03-08 | 2013-03-08 | 1d |  |  |  | Client; Manager | 16h | 16h |
| 7 | 1.1.5 | Define launch goals (launch timing and publicity objectives) |  | 1d | 2013-03-11 A | 2013-03-11 A | 6 | 100% |  | 2013-03-11 | 2013-03-11 | 1d |  |  |  | Client; Manager | 16h | 16h |
| 8 | 1.1.6 | Send RFQ |  | 1d | 2013-03-12 A | 2013-03-12 A | 7 | 100% |  | 2013-03-12 | 2013-03-12 | 1d |  |  |  | Manager | 8h | 8h |
| 9 | 1.1.7 | Identify technology partners |  | 1d | 2013-03-13 A | 2013-03-13 A | 8 | 100% |  | 2013-03-13 | 2013-03-13 | 1d |  |  |  | Manager | 8h | 8h |
| 10 | 1.1.8 | Planning COMPLETE | milestone | 0d | 2013-03-13 A | 2013-03-13 A | 9 | 100% |  | 2013-03-13 | 2013-03-13 | 0d |  |  |  |  |  |  |
| 11 | 1.2 | **Phase 2 - Development** |  | 22d | 2013-03-14 A | 2013-04-12 |  | 72% | 6.11d | 2013-03-14 | 2013-04-08 | 18d | 5d |  |  |  | 176h | 136h |
| 12 | 1.2.1 | Define creative brief |  | 3d | 2013-03-14 A | 2013-03-18 A | 10 | 100% |  | 2013-03-14 | 2013-03-18 | 3d |  |  |  | Client; Manager | 48h | 48h |
| 13 | 1.2.2 | Set design scope |  | 1d | 2013-03-19 A | 2013-03-19 A | 12 | 100% |  | 2013-03-19 | 2013-03-19 | 1d |  |  |  | Client; Manager | 16h | 16h |
| 14 | 1.2.3 | Create design |  | 4d | 2013-03-25 A | 2013-03-28 A | 13 | 100% |  | 2013-03-20 | 2013-03-25 | 4d |  |  | must start on 2013-03-25 | Designer | 32h | 32h |
| 15 | 1.2.4 | Create code |  | 2w | 2013-03-25 A | 2013-04-12 | 14SS | 50% | 1w | 2013-03-26 | 2013-04-08 | 2w | 5d | 0d |  | Developer | 80h | 40h |
| 16 | 1.2.5 | Development Phase COMPLETE | milestone | 0d | 2013-04-12 | 2013-04-12 | 15 |  |  | 2013-04-08 | 2013-04-08 | 0d | 5d |  |  |  |  |  |
| 17 | 1.3 | **Phase 3 - Execution** |  | 1d | 2013-04-22 | 2013-04-22 |  |  |  | 2013-04-09 | 2013-04-09 | 1d | 0d |  |  |  | 8h |  |
| 18 | 1.3.1 | Upload fles and data |  | 1d | 2013-04-22 | 2013-04-22 | 16 |  |  | 2013-04-09 | 2013-04-09 | 1d | 0d |  | start no earlier than 2013-04-22 | Developer | 8h |  |
| 19 | 1.3.2 | Launch Site | milestone | 0d | 2013-04-22 | 2013-04-22 | 18 |  |  | 2013-04-09 | 2013-04-09 | 0d | 0d |  |  |  |  |  |
