# New Product Launch

Schedule from MS Project, 2013-03-04 to 2013-04-09.

## Calendars

- Standard: Mon-Fri 08:00-12:00, 13:00-17:00; Sat-Sun off.

## Resources

| Resource |
| --- |
| Manager |
| Designer |
| Developer |
| Client |

## Schedule

| ID | WBS | Task | Type | Duration | Start | Finish | Predecessors | Baseline start | Baseline finish | Baseline duration | Total slack | Resources | Work |
| --- | --- | --- | --- | --- | --- | --- | --- | --- | --- | --- | --- | --- | --- |
| 1 | 1 | **New Site Launch Preparation** |  | 27d | 2013-03-04 | 2013-04-09 |  | 2013-03-04 | 2013-04-09 | 27d | 0d |  | 280h |
| 2 | 1.1 | **Phase 1 - Planning** |  | 8d | 2013-03-04 | 2013-03-13 |  | 2013-03-04 | 2013-03-13 | 8d | 0d |  | 96h |
| 3 | 1.1.1 | Identify the launch team |  | 2d | 2013-03-04 | 2013-03-05 |  | 2013-03-04 | 2013-03-05 | 2d | 0d | Manager | 16h |
| 4 | 1.1.2 | Determine site objectives |  | 1d | 2013-03-06 | 2013-03-06 | 3 | 2013-03-06 | 2013-03-06 | 1d | 0d | Client; Manager | 16h |
| 5 | 1.1.3 | Identify budget requirements |  | 1d | 2013-03-07 | 2013-03-07 | 4 | 2013-03-07 | 2013-03-07 | 1d | 0d | Client; Manager | 16h |
| 6 | 1.1.4 | Obtain launch budget approval |  | 1d | 2013-03-08 | 2013-03-08 | 5 | 2013-03-08 | 2013-03-08 | 1d | 0d | Client; Manager | 16h |
| 7 | 1.1.5 | Define launch goals (launch timing and publicity objectives) |  | 1d | 2013-03-11 | 2013-03-11 | 6 | 2013-03-11 | 2013-03-11 | 1d | 0d | Client; Manager | 16h |
| 8 | 1.1.6 | Send RFQ |  | 1d | 2013-03-12 | 2013-03-12 | 7 | 2013-03-12 | 2013-03-12 | 1d | 0d | Manager | 8h |
| 9 | 1.1.7 | Identify technology partners |  | 1d | 2013-03-13 | 2013-03-13 | 8 | 2013-03-13 | 2013-03-13 | 1d | 0d | Manager | 8h |
| 10 | 1.1.8 | Planning COMPLETE | milestone | 0d | 2013-03-13 | 2013-03-13 | 9 | 2013-03-13 | 2013-03-13 | 0d | 0d |  |  |
| 11 | 1.2 | **Phase 2 - Development** |  | 18d | 2013-03-14 | 2013-04-08 |  | 2013-03-14 | 2013-04-08 | 18d | 0d |  | 176h |
| 12 | 1.2.1 | Define creative brief |  | 3d | 2013-03-14 | 2013-03-18 | 10 | 2013-03-14 | 2013-03-18 | 3d | 0d | Client; Manager | 48h |
| 13 | 1.2.2 | Set design scope |  | 1d | 2013-03-19 | 2013-03-19 | 12 | 2013-03-19 | 2013-03-19 | 1d | 0d | Client; Manager | 16h |
| 14 | 1.2.3 | Create design |  | 4d | 2013-03-20 | 2013-03-25 | 13 | 2013-03-20 | 2013-03-25 | 4d | 0d | Designer | 32h |
| 15 | 1.2.4 | Create code |  | 2w | 2013-03-26 | 2013-04-08 | 14 | 2013-03-26 | 2013-04-08 | 2w | 0d | Developer | 80h |
| 16 | 1.2.5 | Development Phase COMPLETE | milestone | 0d | 2013-04-08 | 2013-04-08 | 15 | 2013-04-08 | 2013-04-08 | 0d | 0d |  |  |
| 17 | 1.3 | **Phase 3 - Execution** |  | 1d | 2013-04-09 | 2013-04-09 |  | 2013-04-09 | 2013-04-09 | 1d | 0d |  | 8h |
| 18 | 1.3.1 | Upload fles and data |  | 1d | 2013-04-09 | 2013-04-09 | 16 | 2013-04-09 | 2013-04-09 | 1d | 0d | Developer | 8h |
| 19 | 1.3.2 | Launch Site | milestone | 0d | 2013-04-09 | 2013-04-09 | 18 | 2013-04-09 | 2013-04-09 | 0d | 0d |  |  |
